# CRON_20807_

Schedule from MS Project, 2022-06-12 to 2022-11-09.

## Calendars

- Estándar: Mon-Sun 08:00-12:00, 14:00-18:00.

## Schedule

| ID | WBS | Task | Duration | Start | Finish | Predecessors | Total slack |
| --- | --- | --- | --- | --- | --- | --- | --- |
| 1 | 1 | **"RECUPERACIÓN DEL LOCAL ESCOLAR 20807 VICENTE JORGE ESTELA ROJAS CON CÓDIGO LOCAL 512374 CENTRO POBLADO CIENEGUILLO SUR - PIURA - PIURA - PIURA"** | 150d | 2022-06-12 | 2022-11-09 |  | 0d |
| 2 | 1.1 | **ESTRUCTURAS** | 150d | 2022-06-12 | 2022-11-09 |  | 0d |
| 3 | 1.1.1 | **OBRAS PROVISIONALES** | 5d | 2022-06-12 | 2022-06-17 |  | 0d |
| 4 | 1.1.1.1 | ALMACÉN, OFICINAS | 3d | 2022-06-12 | 2022-06-15 |  | 0d |
| 5 | 1.1.1.2 | CARTEL DE OBRA DE 3.60 X 2.40 m | 1d | 2022-06-12 | 2022-06-13 | 4SS | 149d |
| 6 | 1.1.1.3 | CERCO PROVISIONAL DE OBRA | 4d | 2022-06-12 | 2022-06-16 | 4SS | 146d |
| 7 | 1.1.1.4 | SERVICIOS HIGIÉNICOS | 1d | 2022-06-12 | 2022-06-13 | 4SS | 149d |
| 8 | 1.1.1.5 | ELABORACION, IMPLEMENTACION Y ADMINISTRACION DEL PLAN DE SEGURIDAD Y SALUD EN EL TRABAJO | 5d | 2022-06-12 | 2022-06-17 | 4SS | 145d |
| 9 | 1.1.1.6 | SUMINISTRO DE DEPOSITOS DE BASURA | 1d | 2022-06-12 | 2022-06-13 | 4SS | 149d |
| 10 | 1.1.1.7 | SUMINISTRO DE IMPLEMENTOS DE SEGURIDAD | 1d | 2022-06-12 | 2022-06-13 | 4SS | 149d |
| 11 | 1.1.1.8 | SEÑALIZACION TEMPORAL AMBIENTAL Y SEGURIDAD | 5d | 2022-06-12 | 2022-06-17 | 4SS | 145d |
| 12 | 1.1.2 | **TRABAJOS PRELIMINARES** | 150d | 2022-06-12 | 2022-11-09 |  | 0d |
| 13 | 1.1.2.1 | TRAZO Y REPLANTEO PRELIMINAR Y CONTROL PERMANENTE DE OBRA | 2d | 2022-06-12 | 2022-06-14 | 4SS | 0d |
| 14 | 1.1.2.2 | LIMPIEZA PERMANENTE Y FINAL DE OBRA | 150d | 2022-06-12 | 2022-11-09 | 4SS | 0d |
| 15 | 1.1.2.3 | MOVILIZACION DE EQUIPO | 1d | 2022-06-12 | 2022-06-13 | 4SS | 149d |
| 16 | 1.1.2.4 | **MITIGACION AMBIENTAL** | 10d | 2022-06-12 | 2022-06-22 |  | 140d |
| 17 | 1.1.2.4.1 | RIEGO DE TERRENO, MATERIAL EXCAVADO Y AGREGADOS | 10d | 2022-06-12 | 2022-06-22 | 4SS | 140d |
| 18 | 1.1.2.4.2 | PREVENCION DE DAÑOS - DERRAME DE COMBUSTIBLES | 10d | 2022-06-12 | 2022-06-22 | 4SS | 140d |
| 19 | 1.1.2.5 | **DESMONTAJES** | 8d | 2022-06-14 | 2022-06-22 |  | 0d |
| 20 | 1.1.2.5.1 | DESMONTAJE DE VENTANAS | 1d | 2022-06-14 | 2022-06-15 | 13 | 0d |
| 21 | 1.1.2.5.2 | DESMONTAJE DE PUERTAS | 1d | 2022-06-15 | 2022-06-16 | 20 | 0d |
| 22 | 1.1.2.5.3 | DESMONTAJE DE APARATOS SANITARIOS | 1d | 2022-06-16 | 2022-06-17 | 21 | 0d |
| 23 | 1.1.2.5.4 | DESMONTAJE DE COBERTURA DE CALAMINA (INCLUYE ESTRUCTURA DE SOPORTE) | 5d | 2022-06-17 | 2022-06-22 | 22 | 0d |
| 24 | 1.1.2.5.5 | DESMONTAJE DE MUROS DE DRYWALL Y TRIPLAY | 5d | 2022-06-17 | 2022-06-22 | 23SS | 0d |

| ID | WBS | Task | Duration | Start | Finish | Predecessors | Total slack | Free slack |
| --- | --- | --- | --- | --- | --- | --- | --- | --- |
| 25 | 1.1.2.6 | **DEMOLICIÓN , REMOCION Y RASQUETEO** | 6d | 2022-06-22 | 2022-06-28 |  | 0d |  |
| 26 | 1.1.2.6.1 | DEMOLICIÓN DE PISO INC. C.P.- F.P. | 5d | 2022-06-22 | 2022-06-27 | 24 | 0d |  |
| 27 | 1.1.2.6.2 | DEMOLICIÓN DE PISO DE SS.HH (INCLUYE TUBERIAS DE AGUA Y DESAGUE) | 1d | 2022-06-22 | 2022-06-23 | 26SS | 139d |  |
| 28 | 1.1.2.6.3 | DEMOLICIÓN DE MUROS DE LADRILLO KK (SOGA Y DE CANTO) | 4d | 2022-06-23 | 2022-06-27 | 26FF | 0d |  |
| 29 | 1.1.2.6.4 | DEMOLICION DE MUROS DE CONCRETO EN CISTERNA Y CASETA DE ELECTROBOMBA | 1d | 2022-06-27 | 2022-06-28 | 28 | 0d |  |
| 30 | 1.1.2.7 | **DESMONTAJE DEL SISTEMA ELECTRICO** | 2d | 2022-06-27 | 2022-06-29 |  | 0d |  |
| 31 | 1.1.2.7.1 | DESMONTAJE DE CENTROS DE LUZ (INCLUYE INTERRUPTORES) | 1d | 2022-06-27 | 2022-06-28 | 29FF | 0d |  |
| 32 | 1.1.2.7.2 | DESMONTAJE DE TOMACORRIENTES | 1d | 2022-06-28 | 2022-06-29 | 31 | 0d |  |
| 33 | 1.1.2.8 | **PLAN PARA VIGILANCIA, PREVENCION Y CONTROL DE COVID 19, PARA EL TRABAJO** | 5d | 2022-06-12 | 2022-06-17 |  | 145d |  |
| 34 | 1.1.2.8.1 | ELABORACION DEL PLAN DE VIGILANCIA Y CONTROL COVID 19 | 1d | 2022-06-12 | 2022-06-13 | 4SS | 145d | 0d |
| 35 | 1.1.2.8.2 | LIMPIEZA Y DESINFECCION DE CENTRO DE TRABAJO | 5d | 2022-06-12 | 2022-06-17 | 34SS | 145d | 0d |
| 36 | 1.1.2.8.3 | LAVADO Y DESINFECCION DE MANOS OBLIGATORIA | 5d | 2022-06-12 | 2022-06-17 | 35SS | 145d | 0d |
| 37 | 1.1.2.8.4 | SENSIBILIZACION DE LA PREVENCION DEL CONTAGIO EN EL CENTRO DE TRABAJO | 1d | 2022-06-12 | 2022-06-13 | 36SS | 147d | 0d |
| 38 | 1.1.2.8.5 | MEDIDAS PREVENTIVAS DE APLICACION COLECTIVA | 1d | 2022-06-12 | 2022-06-13 | 37SS | 147d | 0d |
| 39 | 1.1.2.8.6 | MEDIDAS DE PROTECCION PERSONAL | 3d | 2022-06-12 | 2022-06-15 | 38SS | 147d |  |
| 40 | 1.1.3 | **MOVIMIENTO DE TIERRAS** | 25d | 2022-06-29 | 2022-07-24 |  | 0d |  |
| 41 | 1.1.3.1 | **CORTE Y EXCAVACION** | 15d | 2022-06-29 | 2022-07-14 |  | 0d |  |
| 42 | 1.1.3.1.1 | EXCAVACION DE ZANJAS PARA CIMENTACION (CIMIENTOS CORRIDOS , PLATEAS Y ZAPATAS) | 15d | 2022-06-29 | 2022-07-14 | 32 | 0d |  |
| 43 | 1.1.3.2 | **RELLENO** | 9d | 2022-07-07 | 2022-07-16 |  | 0d |  |
| 44 | 1.1.3.2.1 | RELLENO COMPACTADO MANUAL MATERIAL PROPIO | 7d | 2022-07-07 | 2022-07-14 | 42FF | 0d |  |
| 45 | 1.1.3.2.2 | RELLENO COMPACTADO MANUAL MATERIAL DE PRESTAMO (AFIRMADO PREPARADO) | 2d | 2022-07-14 | 2022-07-16 | 44 | 0d |  |
| 46 | 1.1.3.2.3 | CAMA DE ARENA EN FONDO DE VIGA CIMENTACION e=0.10m | 1d | 2022-07-15 | 2022-07-16 | 45FF | 0d |  |
| 47 | 1.1.3.3 | **CONFORMACION,NIVELACION Y REFINE** | 5d | 2022-07-16 | 2022-07-21 |  | 0d |  |
| 48 | 1.1.3.3.1 | NIVELACION DE TERRENO Y COMPACTACION | 5d | 2022-07-16 | 2022-07-21 | 46 | 0d |  |

| ID | WBS | Task | Duration | Start | Finish | Predecessors | Total slack | Free slack |
| --- | --- | --- | --- | --- | --- | --- | --- | --- |
| 49 | 1.1.3.4 | **MEJORAMIENTO DE TERRENO** | 1d | 2022-07-21 | 2022-07-22 |  | 0d |  |
| 50 | 1.1.3.4.1 | MEJORAMIENTO DE TERRENO NATURAL e=35 cm (50% OVER+30% CONFITILLO+ 20% ARENA GRUESA | 1d | 2022-07-21 | 2022-07-22 | 48 | 0d |  |
| 51 | 1.1.3.5 | **ACARREO Y ELIMINACION DE MATERIAL** | 10d | 2022-07-14 | 2022-07-24 |  | 108d |  |
| 52 | 1.1.3.5.1 | ACARREO INTERNO MATERIAL PROCEDENTE DE EXCAVACIONES (Dprom=30m) | 10d | 2022-07-14 | 2022-07-24 | 42 | 108d | 0d |
| 53 | 1.1.3.5.2 | ELIMINACION DE MATERIAL EXCEDENTE CON MAQUINARIA (Dprom=5 km) | 2d | 2022-07-22 | 2022-07-24 | 52FF | 108d |  |
| 54 | 1.1.4 | **CONCRETO SIMPLE** | 26d | 2022-07-22 | 2022-08-17 |  | 0d |  |
| 55 | 1.1.4.1 | **SOLADO** | 7d | 2022-07-22 | 2022-07-29 |  | 0d |  |
| 56 | 1.1.4.1.1 | SOLADO e=4", 1:12 C/H | 7d | 2022-07-22 | 2022-07-29 | 50 | 0d |  |
| 57 | 1.1.4.2 | **FALSO PISO** | 3d | 2022-08-14 | 2022-08-17 |  | 11d |  |
| 58 | 1.1.4.2.1 | FALSO PISO MEZCLA 1:8 e=4" | 3d | 2022-08-14 | 2022-08-17 | 78 | 11d | 0d |
| 59 | 1.1.4.3 | **CIMIENTOS** | 7d | 2022-07-29 | 2022-08-05 |  | 96d |  |
| 60 | 1.1.4.3.1 | CIMIENTOS CORRIDOS 1:10 + 30% P.G. FC=100 Kg/cm2 | 7d | 2022-07-29 | 2022-08-05 | 56 | 96d |  |
| 61 | 1.1.5 | **CONCRETO ARMADO** | 59d | 2022-07-29 | 2022-09-26 |  | 0d |  |
| 62 | 1.1.5.1 | **SOBRECIMIENTO** | 19d | 2022-08-14 | 2022-09-02 |  | 2d |  |
| 63 | 1.1.5.1.1 | SOBRECIMIENTOS.-CONCRETO f'c=175 kg/cm2 | 6d | 2022-08-27 | 2022-09-02 | 65FS-3d | 2d | 0d |
| 64 | 1.1.5.1.2 | SOBRECIMIENTO, ENCOFRADO Y DESENCOFRADO | 10d | 2022-08-14 | 2022-08-24 | 78 | 2d | 0d |
| 65 | 1.1.5.1.3 | SOBRECIMIENTO.-ACERO fy=4200 kg/cm2 | 10d | 2022-08-20 | 2022-08-30 | 64FS-4d | 2d | 0d |
| 66 | 1.1.5.2 | **ZAPATAS** | 7d | 2022-07-29 | 2022-08-05 |  | 0d |  |
| 67 | 1.1.5.2.1 | ZAPATAS.-CONCRETO f'c=210 kg/cm2 | 2d | 2022-08-03 | 2022-08-05 | 69 | 0d |  |
| 68 | 1.1.5.2.2 | ZAPATAS.- ENCOFRADO Y DESENCOFRADO | 1d | 2022-07-29 | 2022-07-30 | 56 | 0d |  |
| 69 | 1.1.5.2.3 | ZAPATAS.-ACERO fy=4200 kg/cm2 | 4d | 2022-07-30 | 2022-08-03 | 68 | 0d |  |
| 70 | 1.1.5.3 | **ZAPATAS CORRIDAS** | 8d | 2022-07-30 | 2022-08-07 |  | 2d |  |
| 71 | 1.1.5.3.1 | ZAPATAS.-CONCRETO f'c=210 kg/cm2 | 2d | 2022-08-05 | 2022-08-07 | 72 | 2d | 0d |
| 72 | 1.1.5.3.2 | ZAPATAS.-ACERO fy=4200 kg/cm2 | 6d | 2022-07-30 | 2022-08-05 | 67FF | 2d | 0d |

| ID | WBS | Task | Duration | Start | Finish | Predecessors | Total slack | Free slack |
| --- | --- | --- | --- | --- | --- | --- | --- | --- |
| 73 | 1.1.5.4 | **VIGAS DE CIMENTACION** | 10d | 2022-08-07 | 2022-08-17 |  | 2d |  |
| 74 | 1.1.5.4.1 | VIGAS DE CIMENTACION.- CONCRETO fc=210kg/cm2 | 1d | 2022-08-16 | 2022-08-17 | 76 | 84d |  |
| 75 | 1.1.5.4.2 | VIGAS DE CIMENTACION.- ENCOFRADO Y DESENCOFRADO | 9d | 2022-08-07 | 2022-08-16 | 71 | 2d | 0d |
| 76 | 1.1.5.4.3 | VIGAS DE CIMENTACION.-ACERO fy=4200 kg/cm2 | 5d | 2022-08-11 | 2022-08-16 | 75FF | 84d | 0d |
| 77 | 1.1.5.5 | **PLATEA DE CIMENTACIÓN** | 7d | 2022-08-07 | 2022-08-14 |  | 2d |  |
| 78 | 1.1.5.5.1 | PLATEA DE CIMENTACION.-CONCRETO f'c=210 kg/cm2 | 1d | 2022-08-13 | 2022-08-14 | 80 | 2d | 0d |
| 79 | 1.1.5.5.2 | PLATEA DE CIMENTACION.- ENCOFRADO Y DESENCOFRADO | 3d | 2022-08-07 | 2022-08-10 | 75SS | 2d | 0d |
| 80 | 1.1.5.5.3 | PLATEA DE CIMENTACION.-ACERO fy=4200 kg/cm2 | 3d | 2022-08-10 | 2022-08-13 | 79 | 2d | 0d |
| 81 | 1.1.5.6 | **COLUMNA** | 30d | 2022-08-05 | 2022-09-04 |  | 0d |  |
| 82 | 1.1.5.6.1 | COLUMNAS - CONCRETO 210 KG/CM2 | 10d | 2022-08-25 | 2022-09-04 | 83 | 0d |  |
| 83 | 1.1.5.6.2 | COLUMNAS.- ENCOFRADO Y DESENCOFRADO | 12d | 2022-08-13 | 2022-08-25 | 84FS-4d | 0d |  |
| 84 | 1.1.5.6.3 | COLUMNAS.-ACERO fy=4200 kg/cm2 | 12d | 2022-08-05 | 2022-08-17 | 67 | 0d |  |
| 85 | 1.1.5.7 | **VIGAS** | 20d | 2022-08-25 | 2022-09-14 |  | 0d |  |
| 86 | 1.1.5.7.1 | VIGAS - CONCRETO 210Kg/cm2 | 4d | 2022-09-10 | 2022-09-14 | 88FF | 0d |  |
| 87 | 1.1.5.7.2 | VIGAS.- ENCOFRADO Y DESENCOFRADO | 10d | 2022-08-25 | 2022-09-04 | 82FF | 0d |  |
| 88 | 1.1.5.7.3 | VIGAS.-ACERO fy=4200 kg/cm2 | 10d | 2022-09-04 | 2022-09-14 | 87 | 0d |  |
| 89 | 1.1.5.8 | **LOSAS ALIGERADAS** | 27d | 2022-08-25 | 2022-09-21 |  | 44d |  |
| 90 | 1.1.5.8.1 | LOSA ALIGERADA - CONCRETO 210 kg/cm2 | 4d | 2022-09-17 | 2022-09-21 | 93 | 44d | 0d |
| 91 | 1.1.5.8.2 | LOSA ALIGERADA.- ENCOFRADO Y DESENCOFRADO | 12d | 2022-08-25 | 2022-09-06 | 87SS | 44d | 0d |
| 92 | 1.1.5.8.3 | LOSA ALIGERADA.-ACERO fy=4200 kg/cm2 | 12d | 2022-09-02 | 2022-09-14 | 91FS-4d | 44d | 0d |
| 93 | 1.1.5.8.4 | LOSA ALIGERADA.- LADR. HUECO 15X30X30 | 3d | 2022-09-14 | 2022-09-17 | 92 | 44d | 0d |
| 94 | 1.1.5.9 | **ESCALERAS** | 5d | 2022-09-02 | 2022-09-07 |  | 63d |  |
| 95 | 1.1.5.9.1 | ESCALERAS.- CONCRETO fc=210 kg/cm2 | 1d | 2022-09-06 | 2022-09-07 | 97 | 63d |  |
| 96 | 1.1.5.9.2 | ESCALERAS.- ENCOFRADO Y DESENCOFRADO | 2d | 2022-09-02 | 2022-09-04 | 87FF | 63d | 0d |
| 97 | 1.1.5.9.3 | ESCALERAS.- ACERO fy=4200 kg/cm2 | 2d | 2022-09-04 | 2022-09-06 | 96 | 63d | 0d |

| ID | WBS | Task | Duration | Start | Finish | Predecessors | Total slack | Free slack |
| --- | --- | --- | --- | --- | --- | --- | --- | --- |
| 98 | 1.1.5.10 | **LOSAS MACIZA** | 7d | 2022-09-19 | 2022-09-26 |  | 44d |  |
| 99 | 1.1.5.10.1 | LOSA MACIZA.-CONCRETO f'c=210 kg/cm2 | 1d | 2022-09-25 | 2022-09-26 | 101 | 44d |  |
| 100 | 1.1.5.10.2 | LOSA MACIZA - ENCOFRADO Y DESENCOFRADO | 2d | 2022-09-19 | 2022-09-21 | 90FF | 44d | 0d |
| 101 | 1.1.5.10.3 | LOSA MACIZA - ACERO CORRUGADO fy=4200 kg/cm2 | 4d | 2022-09-21 | 2022-09-25 | 100 | 44d | 0d |
| 102 | 1.1.5.11 | **CUNETAS CON REJILLA** | 10d | 2022-09-13 | 2022-09-23 |  | 33d |  |
| 103 | 1.1.5.11.1 | CUNETAS.-CONCRETO f'c=175 kg/cm2 | 1d | 2022-09-22 | 2022-09-23 | 105 | 33d | 0d |
| 104 | 1.1.5.11.2 | CUNETAS.- ENCOFRADO Y DESENCOFRADO | 5d | 2022-09-13 | 2022-09-18 | 161 | 33d | 0d |
| 105 | 1.1.5.11.3 | CUNETAS.-ACERO fy=4200 kg/cm2 | 4d | 2022-09-18 | 2022-09-22 | 104 | 33d | 0d |
| 106 | 1.1.5.12 | **CISTERNA** | 6d | 2022-08-14 | 2022-08-20 |  | 81d |  |
| 107 | 1.1.5.12.1 | CISTERNA.-CONCRETO f'c=210 kg/cm2 | 1d | 2022-08-19 | 2022-08-20 | 109 | 81d |  |
| 108 | 1.1.5.12.2 | CISTERNA.- ENCOFRADO Y DESENCOFRADO | 2d | 2022-08-14 | 2022-08-16 | 78 | 81d | 0d |
| 109 | 1.1.5.12.3 | CISTERNA.-ACERO fy=4200 kg/cm2 | 3d | 2022-08-16 | 2022-08-19 | 108 | 81d | 0d |
| 110 | 1.1.6 | **ESTRUCTURAS METALICAS** | 56d | 2022-09-14 | 2022-11-09 |  | 0d |  |
| 111 | 1.1.6.1 | **PATIO DE FORMACION** | 53d | 2022-09-14 | 2022-11-06 |  | 0d |  |
| 112 | 1.1.6.1.1 | TIJERAL T-1(HABILITACION Y MONTAJE) | 4d | 2022-09-14 | 2022-09-18 | 86 | 0d |  |
| 113 | 1.1.6.1.2 | VIGUETA METALICA VG1 (HABILITACIÓN Y MONTAJE) | 3d | 2022-09-18 | 2022-09-21 | 112 | 40d | 0d |
| 114 | 1.1.6.1.3 | TENSORES | 3d | 2022-09-18 | 2022-09-21 | 113FF | 49d |  |
| 115 | 1.1.6.1.4 | TEMPLADOR Y CRUZ DE SAN ANDRES | 2d | 2022-09-21 | 2022-09-23 | 113 | 40d | 0d |
| 116 | 1.1.6.1.5 | APOYOS METALICOS FIJO Y MOVIL | 3d | 2022-09-15 | 2022-09-18 | 112FF | 52d |  |
| 117 | 1.1.6.1.6 | CANALETA FG 1.6MM | 2d | 2022-11-04 | 2022-11-06 | 132 | 3d |  |
| 118 | 1.1.6.1.7 | IZAJE DE TIJERALES PATIO DE FORMACION | 4d | 2022-09-14 | 2022-09-18 | 112SS | 52d |  |
| 119 | 1.1.6.1.8 | IZAJE DE VIGUETAS PATIO DE FORMACION | 3d | 2022-09-18 | 2022-09-21 | 113SS | 49d |  |
| 120 | 1.1.6.2 | **PLATAFORMA DEPORTIVA** | 53d | 2022-09-14 | 2022-11-06 |  | 0d |  |
| 121 | 1.1.6.2.1 | PORTICO METALICO PARABOLICO | 10d | 2022-09-14 | 2022-09-24 | 112SS | 0d |  |
| 122 | 1.1.6.2.2 | VIGUETA METALICA VG-1 | 10d | 2022-09-24 | 2022-10-04 | 121 | 0d |  |
| 123 | 1.1.6.2.3 | TENSORES | 8d | 2022-10-11 | 2022-10-19 | 124 | 0d |  |
| 124 | 1.1.6.2.4 | TEMPLADOR Y CRUZ DE SAN ANDRES | 4d | 2022-10-07 | 2022-10-11 | 125FF | 0d |  |
| 125 | 1.1.6.2.5 | ARRIOSTRES DE VIGUETAS EN CRUZ | 7d | 2022-10-04 | 2022-10-11 | 126 | 0d |  |
| 126 | 1.1.6.2.6 | APOYOS METALICOS FIJO Y MOVIL | 4d | 2022-09-30 | 2022-10-04 | 122FF | 0d |  |
| 127 | 1.1.6.2.7 | CANALETA FG 1.6MM | 2d | 2022-11-04 | 2022-11-06 | 132 | 3d |  |
| 128 | 1.1.6.2.8 | IZAJE DE TIJERALES PLATAFORMA DEPORTIVA | 10d | 2022-09-14 | 2022-09-24 | 121SS | 46d |  |
| 129 | 1.1.6.2.9 | IZAJE DE VIGUETAS PLATAFORMA DEPORTIVA | 10d | 2022-09-24 | 2022-10-04 | 122SS | 36d |  |

| ID | WBS | Task | Duration | Start | Finish | Predecessors | Total slack | Free slack |
| --- | --- | --- | --- | --- | --- | --- | --- | --- |
| 130 | 1.1.6.3 | **COBERTURA** | 42d | 2022-09-23 | 2022-11-04 |  | 5d |  |
| 131 | 1.1.6.3.1 | COBERTURA LIVIANA PATIO DE FORMACION | 7d | 2022-09-23 | 2022-09-30 | 115 | 40d |  |
| 132 | 1.1.6.3.2 | COBERTURA LIVIANA CURVA PLATAFORMA DEPORTIVA | 16d | 2022-10-19 | 2022-11-04 | 123 | 0d |  |
| 133 | 1.1.6.4 | **CANALETA DE EVACUACION PLUVIAL** | 5d | 2022-11-04 | 2022-11-09 |  | 0d |  |
| 134 | 1.1.6.4.1 | CANALETA DE EVACUACION PLUVIAL CON PLANCHA GALVANIZADA 1/27" | 5d | 2022-11-04 | 2022-11-09 | 132 | 0d |  |
| 135 | 1.2 | **ARQUITECTURA** | 81d | 2022-08-17 | 2022-11-06 |  | 3d |  |
| 136 | 1.2.1 | **MUROS Y TABIQUES DE ALBAÑILERIA** | 30d | 2022-09-02 | 2022-10-02 |  | 2d |  |
| 137 | 1.2.1.1 | MURO DE LADRILLO KK TIPO IV SOGA M : 1:1:4 e=1.5cm | 14d | 2022-09-02 | 2022-09-16 | 63 | 2d | 0d |
| 138 | 1.2.1.2 | MURO DE LADRILLO KK TIPO IV CABEZA M : 1:1:4 e=1.5cm | 9d | 2022-09-07 | 2022-09-16 | 137FF | 54d |  |
| 139 | 1.2.1.3 | MURO CARAVISTA (DE SOGA DEL CERCO PERIMETRICO) | 30d | 2022-09-02 | 2022-10-02 | 63 | 38d |  |
| 140 | 1.2.1.4 | MURO DE DRYWALL DOBLE ESTRUCTURA e= 1.5cm | 2d | 2022-09-19 | 2022-09-21 | 157 | 49d |  |
| 141 | 1.2.2 | **REVOQUES Y REVESTIMIENTOS** | 39d | 2022-09-15 | 2022-10-24 |  | 2d |  |
| 142 | 1.2.2.1 | TARRAJEO DEL TIPO RAYADO O PRIMARIO CON MORTERO 1:5 | 8d | 2022-09-16 | 2022-09-24 | 137 | 2d | 0d |
| 143 | 1.2.2.2 | TARRAJEO EN MUROS INTERIORES | 9d | 2022-09-15 | 2022-09-24 | 142FF | 2d | 0d |
| 144 | 1.2.2.3 | TARRAJEO EN MUROS EXTERIORES | 9d | 2022-09-15 | 2022-09-24 | 143FF | 2d | 0d |
| 145 | 1.2.2.4 | TARRAJEO DE COLUMNAS | 12d | 2022-09-24 | 2022-10-06 | 144 | 2d | 0d |
| 146 | 1.2.2.5 | TARRAJEO DE VIGAS | 8d | 2022-10-06 | 2022-10-14 | 145 | 2d | 0d |
| 147 | 1.2.2.6 | TARRAJEO CON IMPERMEABILIZANTE | 5d | 2022-10-09 | 2022-10-14 | 146FF | 26d |  |
| 148 | 1.2.2.7 | TARRAJEO DE SOBRECIMIENTO DE CERCO PERIMETRICO | 12d | 2022-09-24 | 2022-10-06 | 142 | 29d | 0d |
| 149 | 1.2.2.8 | VESTIDURA DE DERRAMES (1:5) | 10d | 2022-10-14 | 2022-10-24 | 146 | 2d | 0d |
| 150 | 1.2.2.9 | BRUÑAS SEGÚN DETALLE | 5d | 2022-10-19 | 2022-10-24 | 149FF | 16d |  |
| 151 | 1.2.3 | **CIELORRASOS** | 15d | 2022-10-09 | 2022-10-24 |  | 2d |  |
| 152 | 1.2.3.1 | CIELORRASO CON MEZCLA C:A 1:5 | 15d | 2022-10-09 | 2022-10-24 | 149FF | 2d | 0d |
| 153 | 1.2.4 | **PISOS Y PAVIMENTOS** | 33d | 2022-08-17 | 2022-09-19 |  | 11d |  |
| 154 | 1.2.4.1 | **CONTRAPISOS** | 15d | 2022-08-17 | 2022-09-01 |  | 11d |  |
| 155 | 1.2.4.1.1 | CONTRAPISO DE 40 mm | 15d | 2022-08-17 | 2022-09-01 | 58 | 11d | 0d |

| ID | WBS | Task | Duration | Start | Finish | Predecessors | Total slack | Free slack |
| --- | --- | --- | --- | --- | --- | --- | --- | --- |
| 156 | 1.2.4.2 | **PISOS** | 18d | 2022-09-01 | 2022-09-19 |  | 11d |  |
| 157 | 1.2.4.2.1 | PISO PORCELANATO 60 x 60 BLANCO- ALTO TRANSITO | 18d | 2022-09-01 | 2022-09-19 | 155 | 11d | 0d |
| 158 | 1.2.4.2.2 | PISO DE CONCRETO EN PATIOS f'c=175kg/cm2; e=15cm FROTACHADO | 10d | 2022-09-01 | 2022-09-11 | 155 | 59d |  |
| 159 | 1.2.4.2.3 | PATIOS.- ENCOFRADO Y DESENCOFRADO | 5d | 2022-09-01 | 2022-09-06 | 155 | 23d | 0d |
| 160 | 1.2.4.3 | **VEREDAS Y RAMPAS** | 7d | 2022-09-06 | 2022-09-13 |  | 33d |  |
| 161 | 1.2.4.3.1 | VEREDAS e=4" DE CONCRETO f'c=175kg/cm2 ACABADO FROTACHADO Y BRUÑADO | 4d | 2022-09-09 | 2022-09-13 | 163 | 33d | 0d |
| 162 | 1.2.4.3.2 | RAMPAS e=4" DE CONCRETO f'c=175kg/cm2 ACABADO FROTACHADO Y BRUÑADO | 1d | 2022-09-09 | 2022-09-10 | 163 | 60d |  |
| 163 | 1.2.4.3.3 | VEREDAS Y RAMPAS.- ENCOFRADO Y DESENCOFRADO | 3d | 2022-09-06 | 2022-09-09 | 159 | 33d | 0d |
| 164 | 1.2.5 | **ZOCALOS Y CONTRAZÓCALOS** | 24d | 2022-09-09 | 2022-10-03 |  | 21d |  |
| 165 | 1.2.5.1 | **ZOCALOS** | 7d | 2022-09-19 | 2022-09-26 |  | 11d |  |
| 166 | 1.2.5.1.1 | ZOCALO PORCELANATO 60 x 60 BLANCO - ALTO TRANSITO | 7d | 2022-09-19 | 2022-09-26 | 157 | 11d | 0d |
| 167 | 1.2.5.2 | **CONTRAZOCALOS** | 24d | 2022-09-09 | 2022-10-03 |  | 28d |  |
| 168 | 1.2.5.2.1 | CONTRAZOCALO DE CEMENTO PULIDO | 12d | 2022-09-09 | 2022-09-21 | 163 | 49d |  |
| 169 | 1.2.5.2.2 | CONTRAZOCALO DE PORCELANATO 20X60 BLANCO - ALTO TRANSITO | 7d | 2022-09-26 | 2022-10-03 | 166 | 11d | 0d |
| 170 | 1.2.6 | **COBERTURAS** | 20d | 2022-10-06 | 2022-10-26 |  | 3d |  |
| 171 | 1.2.6.1 | COBERTURA CON PLANCHA CALAMINON TAT 1060 TERMO-AISLANTE e=25mm (INC. ESTRUCTURA DE SOPORTE METALICA) | 15d | 2022-10-11 | 2022-10-26 | 172 | 3d | 0d |
| 172 | 1.2.6.2 | IMPERMEABILIZANTE DE TECHOS CON PINTURA ASFALTICA | 5d | 2022-10-06 | 2022-10-11 | 145 | 3d | 0d |
| 173 | 1.2.7 | **CARPINTERIA DE MADERA** | 28d | 2022-10-03 | 2022-10-31 |  | 9d |  |
| 174 | 1.2.7.1 | PUERTA MACHIEMBRADA | 5d | 2022-10-03 | 2022-10-08 | 169 | 11d | 0d |
| 175 | 1.2.7.2 | PUERTA CONTRAPLACADA 40 mm CON TRIPLAY 6 mm INCLUYE MARCO CEDRO 2"x4" | 4d | 2022-10-08 | 2022-10-12 | 174 | 11d | 0d |
| 176 | 1.2.7.3 | PIZARRA ACRILICA | 2d | 2022-10-29 | 2022-10-31 | 202 | 9d |  |
| 177 | 1.2.8 | **CARPINTERIA METALICA Y HERRERÍA** | 41d | 2022-09-23 | 2022-11-03 |  | 6d |  |
| 178 | 1.2.8.1 | CANTONERA DE FIERRO EN ESCALERA | 3d | 2022-10-24 | 2022-10-27 | 149 | 9d | 0d |
| 179 | 1.2.8.2 | PUERTAS DE INGRESOS PRINCIPALES | 4d | 2022-10-27 | 2022-10-31 | 178 | 9d | 0d |
| 180 | 1.2.8.3 | ASTA DE BANDERA | 1d | 2022-10-30 | 2022-10-31 | 179FF | 9d |  |
| 181 | 1.2.8.4 | BARANDA METALICA EN ESCALERA | 1d | 2022-10-26 | 2022-10-27 | 178FF | 13d |  |
| 182 | 1.2.8.5 | REJILLA METALICA PARA CUNETA DE 1"X1"X1/8" (INCLUYE COLOCACION) | 5d | 2022-09-23 | 2022-09-28 | 103 | 33d | 0d |
| 183 | 1.2.8.6 | SUMINISTRO E INSTALACION DE ENCUENTRO METALICO ENTRE SOBRETECHO Y PARAPETO | 4d | 2022-10-26 | 2022-10-30 | 171 | 3d | 0d |
| 184 | 1.2.8.7 | SUMINISTRO E INSTALACION DE CANALETA DE EVACUACION PLUVIAL 610 mm | 3d | 2022-10-30 | 2022-11-02 | 183 | 3d | 0d |
| 185 | 1.2.8.8 | BATERIAS ECOLOGICAS DE TRES TACHOS | 1d | 2022-11-02 | 2022-11-03 | 184 | 3d | 0d |
| 186 | 1.2.8.9 | ESCALERA DE GATO DE FIERRO GALVANIZADO | 1d | 2022-09-28 | 2022-09-29 | 182 | 33d | 0d |
| 187 | 1.2.8.10 | ESCALERA DE ALUMINIO EN CISTERNA | 1d | 2022-09-29 | 2022-09-30 | 186 | 33d | 0d |
| 188 | 1.2.8.11 | PUERTA DE CASETA DE ELECTROBOMBA | 1d | 2022-09-30 | 2022-10-01 | 187 | 33d | 0d |
| 189 | 1.2.8.12 | TUBOS METÁLICOS EN CERCO PERIMÉTRICO | 4d | 2022-10-01 | 2022-10-05 | 188 | 33d | 0d |

| ID | WBS | Task | Duration | Start | Finish | Predecessors | Total slack | Free slack |
| --- | --- | --- | --- | --- | --- | --- | --- | --- |
| 190 | 1.2.9 | **VENTANAS DE ALUMINIO CON PROTECTOR, CRISTAL Y VIDRIOS** | 12d | 2022-10-12 | 2022-10-24 |  | 11d |  |
| 191 | 1.2.9.1 | SUMINISTRO E INSTALACION DE VENTANA DE ALUMINIO CON CRISTAL CRUDO DE 6 mm INCOLORO + LAMINA DE SEGURIDAD DE 4 MICRAS Y PROTECTOR DE SEGURIDAD | 12d | 2022-10-12 | 2022-10-24 | 175 | 11d | 0d |
| 192 | 1.2.9.2 | SUMINISTRO E INSTALACION DE PROTECTORES DE SEGURIDAD DE ALUMINIO | 8d | 2022-10-16 | 2022-10-24 | 191FF | 11d | 0d |
| 193 | 1.2.10 | **CERRAJERIA** | 5d | 2022-10-24 | 2022-10-29 |  | 11d |  |
| 194 | 1.2.10.1 | BISAGRA ALUMINIZADA DE 4" PESADA EN PUERTAS | 5d | 2022-10-24 | 2022-10-29 | 192 | 11d | 0d |
| 195 | 1.2.10.2 | BISAGRA ALUMINIZADA DE 3" PESADA EN PUERTAS | 2d | 2022-10-27 | 2022-10-29 | 194FF | 11d | 0d |
| 196 | 1.2.10.3 | CERRADURA TRES GOLPES CON TIRADOR EN PUERTAS | 2d | 2022-10-27 | 2022-10-29 | 195FF | 11d | 0d |
| 197 | 1.2.10.4 | CHAPA DE POMO CON PESTILLO EN PUERTA | 1d | 2022-10-28 | 2022-10-29 | 196FF | 11d | 0d |
| 198 | 1.2.10.5 | PICAPORTE EN PUERTAS DE SS.HH | 1d | 2022-10-28 | 2022-10-29 | 197FF | 11d |  |
| 199 | 1.2.10.6 | CANDADO DE 60mm | 1d | 2022-10-28 | 2022-10-29 | 197FF | 11d |  |
| 200 | 1.2.11 | **PINTURA** | 24d | 2022-10-05 | 2022-10-29 |  | 11d |  |
| 201 | 1.2.11.1 | PINTURA LATEX 2 MANOS EN MUROS Y COLUMNAS | 10d | 2022-10-06 | 2022-10-16 | 145 | 22d | 0d |
| 202 | 1.2.11.2 | PINTURA LATEX 2 MANOS EN CIELO RASO Y VIGAS | 5d | 2022-10-24 | 2022-10-29 | 152 | 2d | 0d |
| 203 | 1.2.11.3 | PINTURA ANTICORROSIVA Y ESMALTE 2 MANOS DE CARPINTERIA METALICA | 2d | 2022-10-05 | 2022-10-07 | 189 | 33d |  |
| 204 | 1.2.11.4 | PINTURA EN PUERTAS DE MADERA | 3d | 2022-10-12 | 2022-10-15 | 175 | 25d |  |
| 205 | 1.2.11.5 | PINTURA LATEX 2 MANOS EN SOBRECIMIENTO | 5d | 2022-10-06 | 2022-10-11 | 148 | 29d |  |
| 206 | 1.2.12 | **JUNTAS** | 54d | 2022-09-13 | 2022-11-06 |  | 3d |  |
| 207 | 1.2.12.1 | JUNTA DE DILATACION EN PISOS CON TECNOPORT DE e= 3/8" RELLENO CON POLIURETANO | 2d | 2022-09-13 | 2022-09-15 | 161 | 55d |  |
| 208 | 1.2.12.2 | JUNTAS DE DILATACION CON ESPUMA PLÁSTICA RELLENO CON POLIURETANO | 3d | 2022-11-03 | 2022-11-06 | 185 | 3d |  |
| 209 | 1.2.12.3 | JUNTAS ASFALTICAS e=1" | 2d | 2022-09-13 | 2022-09-15 | 161 | 55d |  |
| 210 | 1.2.13 | **VARIOS** | 35d | 2022-09-13 | 2022-10-18 |  | 22d |  |
| 211 | 1.2.13.1 | CURADO CON CURADOR QUIMICO PARA CONCRETO | 4d | 2022-09-13 | 2022-09-17 | 161 | 53d |  |
| 212 | 1.2.13.2 | SUMINISTRO E INSTALACION DE STICKER PARA SEÑALITICA DE SEGURIDAD | 2d | 2022-10-16 | 2022-10-18 | 201 | 22d | 0d |
| 213 | 1.2.13.3 | SUMINISTRO E INSTALACION DE EXTINTOR DE POLVO QUIMICO SECO | 1d | 2022-10-16 | 2022-10-17 | 212SS | 23d |  |
| 214 | 1.2.13.4 | MESA CORRIDA DE CONCRETO REVEST. C/PORCELANATO | 3d | 2022-09-19 | 2022-09-22 | 157 | 48d |  |

| ID | WBS | Task | Duration | Start | Finish | Predecessors | Total slack | Free slack |
| --- | --- | --- | --- | --- | --- | --- | --- | --- |
| 215 | 1.3 | **INSTALACIONES SANITARIAS** | 46d | 2022-09-01 | 2022-10-17 |  | 23d |  |
| 216 | 1.3.1 | **MOVIMIENTO DE TIERRAS** | 16d | 2022-09-06 | 2022-09-22 |  | 23d |  |
| 217 | 1.3.1.1 | EXCAVACION DE ZANJAS PARA H=0.80m, PARA TUBERIA DE 4" | 2d | 2022-09-06 | 2022-09-08 | 159 | 23d | 0d |
| 218 | 1.3.1.2 | EXCAVACION DE ZANJAS MANUAL H<=3.00m | 5d | 2022-09-08 | 2022-09-13 | 217 | 23d | 0d |
| 219 | 1.3.1.3 | RELLENO C/ARENA HASTA e=0.20m LA CLAVE PARA TUBO DE 4" | 2d | 2022-09-13 | 2022-09-15 | 218 | 55d |  |
| 220 | 1.3.1.4 | RELLENO Y COMPACTACION DE ZANJAS C/ MATERIAL PROPIO CON EQUIPO H=0.8m | 5d | 2022-09-13 | 2022-09-18 | 218 | 23d | 0d |
| 221 | 1.3.1.5 | REFINE, NIVELACION DE ZANJAS P/TUBO DE 4" | 2d | 2022-09-18 | 2022-09-20 | 220 | 23d | 0d |
| 222 | 1.3.1.6 | CAMA DE ARENA GRUESA e=0.10m PARA TUBO DE 4" | 2d | 2022-09-20 | 2022-09-22 | 221 | 23d | 0d |
| 223 | 1.3.2 | **SISTEMA DE AGUA POTABLE EXTERIOR** | 5d | 2022-09-22 | 2022-09-27 |  | 23d |  |
| 224 | 1.3.2.1 | TUBERIA PVC-SAP 3/4" CLASE 10 | 2d | 2022-09-22 | 2022-09-24 | 222 | 23d | 0d |
| 225 | 1.3.2.2 | VALVULA TIPO BOLA 1 1/2" | 1d | 2022-09-24 | 2022-09-25 | 224 | 29d | 0d |
| 226 | 1.3.2.3 | CAJA PREFABRICADA P/VALVULAS | 1d | 2022-09-25 | 2022-09-26 | 225 | 29d | 0d |
| 227 | 1.3.2.4 | SUMINISTRO E INSTALACION DE TANQUE DE AGUA DE POLIETILENO (2,500L) | 1d | 2022-09-26 | 2022-09-27 | 226 | 29d | 0d |
| 228 | 1.3.3 | **SISTEMA DE RIEGO** | 1d | 2022-09-24 | 2022-09-25 |  | 45d |  |
| 229 | 1.3.3.1 | LLAVE DE RIEGO C/GRIFO DE ½" EN CAJUELA CONCRETO F'c 140 S/D | 1d | 2022-09-24 | 2022-09-25 | 224 | 45d |  |
| 230 | 1.3.4 | **SISTEMA DE DESAGUE EXTERIOR** | 9d | 2022-09-24 | 2022-10-03 |  | 23d |  |
| 231 | 1.3.4.1 | TUBERIA DE PVC SAL 4" | 3d | 2022-09-24 | 2022-09-27 | 224 | 23d | 0d |
| 232 | 1.3.4.2 | CAJA DE REGISTRO PREFABRICADA DE 12" X 24" CON TAPA DE CONCRETO | 4d | 2022-09-27 | 2022-10-01 | 231 | 35d | 0d |
| 233 | 1.3.4.3 | CAJA DE REGISTRO DE ALBAÑILERIA DE 24" X 24" CON TAPA DE CONCRETO | 1d | 2022-10-01 | 2022-10-02 | 232 | 35d | 0d |
| 234 | 1.3.4.4 | SUMINISTRO E INSTALACION DE BIODIGESTOR | 1d | 2022-10-02 | 2022-10-03 | 233 | 35d | 0d |
| 235 | 1.3.5 | **PRUEBA HIDRAULICA DE CISTERNA, TANQUE Y SISTEMA DE BOMBEO** | 2d | 2022-10-03 | 2022-10-05 |  | 35d |  |
| 236 | 1.3.5.1 | PRUEBA HIDRAULICA DE CISTERNA Y EQUIPO DE BOMBEO | 2d | 2022-10-03 | 2022-10-05 | 234 | 35d |  |
| 237 | 1.3.6 | **APARATOS SANITARIOS Y ACCESORIOS** | 17d | 2022-09-22 | 2022-10-09 |  | 25d |  |
| 238 | 1.3.6.1 | INODORO TANQUE BAJO DE LOSA INCLUYE ACCESORIOS | 3d | 2022-09-26 | 2022-09-29 | 166 | 21d | 0d |
| 239 | 1.3.6.2 | URINARIOS DE LOZA DE PICO | 1d | 2022-09-29 | 2022-09-30 | 238 | 21d | 0d |
| 240 | 1.3.6.3 | LAVATORIO DE LOZA BLANCA | 3d | 2022-09-30 | 2022-10-03 | 239 | 21d | 0d |
| 241 | 1.3.6.4 | DISPENSADOR DE JABON LIQUIDO | 1d | 2022-10-03 | 2022-10-04 | 240 | 21d | 0d |
| 242 | 1.3.6.5 | PAPELERA DE CERAMICA | 1d | 2022-10-04 | 2022-10-05 | 241 | 21d | 0d |
| 243 | 1.3.6.6 | TRAMPA DE GRASA TIPO HEVEX MODELO IG-20 | 1d | 2022-10-05 | 2022-10-06 | 242 | 21d | 0d |
| 244 | 1.3.6.7 | ESPEJO BISELADO | 1d | 2022-10-06 | 2022-10-07 | 243 | 21d | 0d |
| 245 | 1.3.6.8 | PAPELERA PLASTICA | 1d | 2022-10-07 | 2022-10-08 | 244 | 31d | 0d |
| 246 | 1.3.6.9 | LAVADERO DE ACERO INOXIDABLE | 1d | 2022-10-08 | 2022-10-09 | 245 | 31d |  |
| 247 | 1.3.6.10 | MESA CORRIDA DE CONCRETO REVEST. C/PORCELANATO | 4d | 2022-09-22 | 2022-09-26 | 166FF | 44d |  |

| ID | WBS | Task | Duration | Start | Finish | Predecessors | Total slack | Free slack |
| --- | --- | --- | --- | --- | --- | --- | --- | --- |
| 248 | 1.3.7 | **INSTALACIONES SANITARIAS DE DESAGUE** | 16d | 2022-09-27 | 2022-10-13 |  | 23d |  |
| 249 | 1.3.7.1 | SALIDA DE DESAGUE EN PVC | 5d | 2022-09-27 | 2022-10-02 | 231 | 23d | 0d |
| 250 | 1.3.7.2 | SALIDA PARA VENTILACION | 3d | 2022-09-27 | 2022-09-30 | 249SS | 23d | 0d |
| 251 | 1.3.7.3 | TUBERIA PVC-SAL 2" | 4d | 2022-09-30 | 2022-10-04 | 250 | 23d | 0d |
| 252 | 1.3.7.4 | TUBERIA PVC-SAL 4" | 3d | 2022-10-04 | 2022-10-07 | 251 | 23d | 0d |
| 253 | 1.3.7.5 | REGISTROS DE BRONCE DE 4" | 2d | 2022-10-07 | 2022-10-09 | 252 | 27d | 0d |
| 254 | 1.3.7.6 | REGISTROS DE BRONCE DE 2" | 2d | 2022-10-09 | 2022-10-11 | 253 | 27d | 0d |
| 255 | 1.3.7.7 | PRUEBA HIDRAULICA Y ESCORRENTIA TUB. DESAGUE | 2d | 2022-10-11 | 2022-10-13 | 254 | 27d |  |
| 256 | 1.3.8 | **INSTALACIONES SANITARIAS DE AGUA** | 10d | 2022-10-07 | 2022-10-17 |  | 23d |  |
| 257 | 1.3.8.1 | SALIDA DE AGUA FRIA.- PVC | 5d | 2022-10-07 | 2022-10-12 | 252 | 23d | 0d |
| 258 | 1.3.8.2 | TUBERIA PVC CLASE 10 - 1/2" ROSCADA | 1d | 2022-10-12 | 2022-10-13 | 257 | 23d | 0d |
| 259 | 1.3.8.3 | TUBERIA PVC CLASE 10 - 3/4" ROSCADA | 1d | 2022-10-13 | 2022-10-14 | 258 | 23d | 0d |
| 260 | 1.3.8.4 | VALVULA DE COMPUERTA DE BRONCE 3/4" | 1d | 2022-10-14 | 2022-10-15 | 259 | 23d | 0d |
| 261 | 1.3.8.5 | CAJA DE MADERA PARA VALVULA | 1d | 2022-10-15 | 2022-10-16 | 260 | 23d | 0d |
| 262 | 1.3.8.6 | PRUEBA HIDRAULICA EN TUBERIA DE AGUA | 1d | 2022-10-16 | 2022-10-17 | 261 | 23d |  |
| 263 | 1.3.9 | **TUBERIAS Y ACCESORIOS TANQUE ELEVADO** | 14d | 2022-09-27 | 2022-10-11 |  | 29d |  |
| 264 | 1.3.9.1 | TUBERIA FIERRO GALVANIZADO 3" | 1d | 2022-09-27 | 2022-09-28 | 227 | 29d | 0d |
| 265 | 1.3.9.2 | TUBERIA DE PVC SAP 2" CLASE 10 | 1d | 2022-09-28 | 2022-09-29 | 264 | 29d | 0d |
| 266 | 1.3.9.3 | TUBERIA DE PVC SAP 2 1/2" CLASE 10 | 1d | 2022-09-29 | 2022-09-30 | 265 | 29d | 0d |
| 267 | 1.3.9.4 | TUBERIA FIERRO GALVANIZADO 2" | 1d | 2022-09-30 | 2022-10-01 | 266 | 29d | 0d |
| 268 | 1.3.9.5 | TUBERIA FIERRO GALVANIZADO 1 1/2" | 1d | 2022-10-01 | 2022-10-02 | 267 | 29d | 0d |
| 269 | 1.3.9.6 | TUBERIA PVC CLASE 10 - 1/2" ROSCADA | 1d | 2022-10-02 | 2022-10-03 | 268 | 29d | 0d |
| 270 | 1.3.9.7 | VALVULA CHECK 2" | 1d | 2022-10-03 | 2022-10-04 | 269 | 36d |  |
| 271 | 1.3.9.8 | VALVULA CHECK 1 1/2" | 1d | 2022-10-03 | 2022-10-04 | 269 | 29d | 0d |
| 272 | 1.3.9.9 | VALVULA DE COMPUERTA DE BRONCE 2" | 1d | 2022-10-04 | 2022-10-05 | 271 | 35d |  |
| 273 | 1.3.9.10 | VALVULA DE COMPUERTA DE BRONCE 1 1/2" | 1d | 2022-10-04 | 2022-10-05 | 271 | 29d | 0d |
| 274 | 1.3.9.11 | VALVULA DE COMPUERTA DE BRONCE 1/2" | 1d | 2022-10-05 | 2022-10-06 | 273 | 29d | 0d |
| 275 | 1.3.9.12 | VALVULA FLOTADORA 1 1/2" | 1d | 2022-10-05 | 2022-10-06 | 273 | 34d |  |
| 276 | 1.3.9.13 | VALVULA FLOTADORA 3/4" | 1d | 2022-10-06 | 2022-10-07 | 274 | 33d |  |
| 277 | 1.3.9.14 | CAJA BAYPAS DE CONCRETO | 1d | 2022-10-06 | 2022-10-07 | 274 | 29d | 0d |
| 278 | 1.3.9.15 | CAJA DE REBOSE CON REJILLA METALICA | 1d | 2022-10-07 | 2022-10-08 | 277 | 29d | 0d |
| 279 | 1.3.9.16 | SUMINISTRO E INSTALACION DE EQUIPO DE BOMBEO | 1d | 2022-10-08 | 2022-10-09 | 278 | 31d |  |
| 280 | 1.3.9.17 | TAPA DE FIERRO EN CISTERNA | 1d | 2022-10-08 | 2022-10-09 | 278 | 31d |  |
| 281 | 1.3.9.18 | REBOSE DE TANQUE ALTO FIERRO GALVAN. 2" | 1d | 2022-10-08 | 2022-10-09 | 278 | 31d |  |
| 282 | 1.3.9.19 | REBOSE DE CISTERNA DE FIERRO GALVANIZADA 4" | 1d | 2022-10-08 | 2022-10-09 | 278 | 29d | 0d |
| 283 | 1.3.9.20 | ABRAZADERA DE FIJACION DE TUBO | 1d | 2022-10-09 | 2022-10-10 | 282 | 29d | 0d |
| 284 | 1.3.9.21 | ROMPE AGUA | 1d | 2022-10-10 | 2022-10-11 | 283 | 29d |  |

| ID | WBS | Task | Duration | Start | Finish | Predecessors | Total slack | Free slack |
| --- | --- | --- | --- | --- | --- | --- | --- | --- |
| 285 | 1.3.10 | **SISTEMA DE DRENAJE PLUVIAL** | 4d | 2022-09-01 | 2022-09-05 |  | 64d |  |
| 286 | 1.3.10.1 | TUBERIA DE BAJADA Y RED PVC SAP 4" | 2d | 2022-09-01 | 2022-09-03 | 155 | 64d | 0d |
| 287 | 1.3.10.2 | SUMINISTRO E INSTALACION TUBERIA PVC 200mm ISO 4435 S-20 | 1d | 2022-09-03 | 2022-09-04 | 286 | 64d | 0d |
| 288 | 1.3.10.3 | CAJA DE REGISTRO PREFABRICADA DE 18" X 24" CON TAPA DE CONCRETO | 1d | 2022-09-04 | 2022-09-05 | 287 | 64d | 0d |
| 289 | 1.3.11 | **RECONEXION A LAS REDES EXISTENTES** | 1d | 2022-09-05 | 2022-09-06 |  | 64d |  |
| 290 | 1.3.11.1 | EMPALME A RED EXISTENTE, AGUA | 1d | 2022-09-05 | 2022-09-06 | 288 | 64d |  |
| 291 | 1.4 | **INSTALACIONES ELECTRICAS** | 101d | 2022-07-29 | 2022-11-07 |  | 2d |  |
| 292 | 1.4.1 | **MOVIMIENTO DE TIERRAS** | 9d | 2022-07-29 | 2022-08-07 |  | 76d |  |
| 293 | 1.4.1.1 | EXCAVACION MANUAL DE ZANJAS PARA CABLE ELECTRICO DE 100 x 100 cm | 4d | 2022-07-29 | 2022-08-02 | 56 | 76d | 0d |
| 294 | 1.4.1.2 | REFINE, NIVELACION DE ZANJAS INCLUYE CAMA DE 100 CM | 1d | 2022-08-02 | 2022-08-03 | 293 | 76d | 0d |
| 295 | 1.4.1.3 | RELLENO Y COMPACTACION MANUAL DE ZANJAS C/ MATERIAL PROPIO CON EQUIPO 100 x 100 cm | 4d | 2022-08-03 | 2022-08-07 | 294 | 76d | 0d |
| 296 | 1.4.2 | **CONDUCTORES, DUCTOS Y ACCESORIOS** | 17d | 2022-08-04 | 2022-08-21 |  | 79d |  |
| 297 | 1.4.2.1 | CONDUCTOR DE Cu DE 2-1x2.5mm2 NH-80 | 1d | 2022-08-07 | 2022-08-08 | 295 | 76d | 0d |
| 298 | 1.4.2.2 | CONDUCTOR DE Cu DE 1-1x2.5mm2 NH-80 | 2d | 2022-08-06 | 2022-08-08 | 297FF | 93d |  |
| 299 | 1.4.2.3 | CONDUCTOR DE Cu DE 2-1x4mm2 NH-80 | 4d | 2022-08-04 | 2022-08-08 | 298FF | 93d |  |
| 300 | 1.4.2.4 | CONDUCTOR DE Cu DE 1-1x4mm2 NH-80 | 4d | 2022-08-08 | 2022-08-12 | 297 | 76d | 0d |
| 301 | 1.4.2.5 | CONDUCTOR DE Cu DE 2-1x4mm2 N2XOH | 1d | 2022-08-11 | 2022-08-12 | 300FF | 89d |  |
| 302 | 1.4.2.6 | CONDUCTOR DE Cu DE 1-1x2.5mm2 N2XOH | 1d | 2022-08-11 | 2022-08-12 | 300FF | 89d |  |
| 303 | 1.4.2.7 | CONDUCTOR DE Cu DE 3-1x10mm2 N2XOH | 1d | 2022-08-11 | 2022-08-12 | 300FF | 89d |  |
| 304 | 1.4.2.8 | CONDUCTOR DE Cu DE 1-1x10mm2 N2XOH | 1d | 2022-08-11 | 2022-08-12 | 300FF | 89d |  |
| 305 | 1.4.2.9 | CONDUCTOR DE Cu DE 3-1x16mm2 N2XOH | 1d | 2022-08-11 | 2022-08-12 | 300FF | 76d | 0d |
| 306 | 1.4.2.10 | CONDUCTOR DE Cu DE 1-1x16mm2 N2XOH | 4d | 2022-08-12 | 2022-08-16 | 305 | 76d | 0d |
| 307 | 1.4.2.11 | TUBERIA PVC-SAP DE 20 MM DE DIAMETRO INC. ACCESORIOS | 1d | 2022-08-15 | 2022-08-16 | 306FF | 85d |  |
| 308 | 1.4.2.12 | TUBERIA PVC-SAP DE 25 MM DE DIAMETRO INC. ACCESORIOS | 1d | 2022-08-15 | 2022-08-16 | 306FF | 85d |  |
| 309 | 1.4.2.13 | TUBERIA PVC-SAP DE 35 MM DE DIAMETRO INC. ACCESORIOS | 1d | 2022-08-15 | 2022-08-16 | 306FF | 85d |  |
| 310 | 1.4.2.14 | CAJA DE DERIVACION DE 200x200x150 | 1d | 2022-08-15 | 2022-08-16 | 306FF | 76d | 0d |
| 311 | 1.4.2.15 | SISTEMA DE TUBERIA CONDUIT EMT INC. ACCESORIOS | 5d | 2022-08-16 | 2022-08-21 | 310 | 76d | 0d |

| ID | WBS | Task | Duration | Start | Finish | Predecessors | Total slack | Free slack |
| --- | --- | --- | --- | --- | --- | --- | --- | --- |
| 312 | 1.4.3 | **ARTEFACTOS DE ILUMINACION - LUMINARIAS / TOMACORRIENTES** | 59d | 2022-08-21 | 2022-10-19 |  | 21d |  |
| 313 | 1.4.3.1 | INDIKO FORYIMO LED - PHILLIPS (LUMINARIA HERMÉTICA) 2 LAMPARA | 4d | 2022-10-07 | 2022-10-11 | 244 | 21d | 0d |
| 314 | 1.4.3.2 | INDIKO FORYIMO LED - PHILLIPS (LUMINARIA HERMÉTICA) 1 LAMPARA | 2d | 2022-10-11 | 2022-10-13 | 313 | 21d | 0d |
| 315 | 1.4.3.3 | BERYL ADOSADA LED 15W | 2d | 2022-10-13 | 2022-10-15 | 314 | 21d | 0d |
| 316 | 1.4.3.4 | LAMPARA DE EMERGENCIA DE 24 LEDS | 2d | 2022-10-15 | 2022-10-17 | 315 | 21d | 0d |
| 317 | 1.4.3.5 | Reflector Josfel Hall Ligth Led 250W asimétrico o EQUIVALENTE | 2d | 2022-10-17 | 2022-10-19 | 316 | 21d |  |
| 318 | 1.4.3.6 | CAJA OCTOGONAL F°G° DE 100mm x 55mm | 3d | 2022-08-21 | 2022-08-24 | 311 | 77d |  |
| 319 | 1.4.3.7 | INTERRUPTOR SIMPLE UNIPOLAR | 2d | 2022-08-21 | 2022-08-23 | 311 | 78d |  |
| 320 | 1.4.3.8 | INTERRUPTOR DOBLE UNIPOLAR | 1d | 2022-08-21 | 2022-08-22 | 311 | 76d | 0d |
| 321 | 1.4.3.9 | TOMACORRIENTE DOBLE C/T | 1d | 2022-08-22 | 2022-08-23 | 320 | 76d | 0d |
| 322 | 1.4.3.10 | CAJA RECTANGULAR F°G° DE 100 x 55 x 50mm | 1d | 2022-08-23 | 2022-08-24 | 321 | 76d | 0d |
| 323 | 1.4.4 | **TABLERO ELECTRICO TRIFASICO/ MONOFASICO** | 1d | 2022-10-06 | 2022-10-07 |  | 30d |  |
| 324 | 1.4.4.1 | TABLERO ELECTRICO DE F°G° EMPOTRADO 8 POLOS | 1d | 2022-10-06 | 2022-10-07 | 201SS | 30d | 0d |
| 325 | 1.4.4.2 | TABLERO ELECTRICO DE F°G° EMPOTRADO 18 POLOS | 1d | 2022-10-06 | 2022-10-07 | 324SS | 33d | 0d |
| 326 | 1.4.5 | **INTERRUPTORES TERMOMAGNETICOS MONOFASICOS** | 1d | 2022-10-07 | 2022-10-08 |  | 32d |  |
| 327 | 1.4.5.1 | INTERRUPTOR THERMOMAGNETICO MONOFASICO 2 X 16A | 1d | 2022-10-07 | 2022-10-08 | 324 | 32d |  |
| 328 | 1.4.5.2 | INTERRUPTOR THERMOMAGNETICO MONOFASICO 2 X 20A | 1d | 2022-10-07 | 2022-10-08 | 324 | 32d |  |
| 329 | 1.4.6 | **INTERRUPTORES DIFERENCIALES** | 1d | 2022-10-07 | 2022-10-08 |  | 30d |  |
| 330 | 1.4.6.1 | INTERRUPTOR DIFERENCIAL 2x20 A/30mm A | 1d | 2022-10-07 | 2022-10-08 | 324 | 32d |  |
| 331 | 1.4.6.2 | INTERRUPTOR DIFERENCIAL 3x40 A/30mm A | 1d | 2022-10-07 | 2022-10-08 | 324 | 32d |  |
| 332 | 1.4.6.3 | INTERRUPTOR DIFERENCIAL 3x63 A/30mm A | 1d | 2022-10-07 | 2022-10-08 | 324 | 30d | 0d |
| 333 | 1.4.7 | **PUESTA A TIERRA DE TABLERO GENERAL** | 2d | 2022-10-08 | 2022-10-10 |  | 30d |  |
| 334 | 1.4.7.1 | POZO CONEXION A TIERRA | 2d | 2022-10-08 | 2022-10-10 | 332 | 30d |  |
| 335 | 1.4.8 | **BUZON ELECTRICO** | 2d | 2022-10-08 | 2022-10-10 |  | 30d |  |
| 336 | 1.4.8.1 | BUZON DEL SISTEMA ELECTRICO 1.00x1.00x0.8 | 2d | 2022-10-08 | 2022-10-10 | 332 | 30d |  |

| ID | WBS | Task | Duration | Start | Finish | Predecessors | Total slack | Free slack |
| --- | --- | --- | --- | --- | --- | --- | --- | --- |
| 337 | 1.4.9 | **ELECTROBOMBA** | 1d | 2022-10-06 | 2022-10-07 |  | 33d |  |
| 338 | 1.4.9.1 | TABLERO DE ELECTROBOMBAS | 1d | 2022-10-06 | 2022-10-07 | 325SS | 33d |  |
| 339 | 1.4.10 | **TRANSPORTE DE MATERIALES** | 1d | 2022-08-24 | 2022-08-25 |  | 76d |  |
| 340 | 1.4.10.1 | TRANSPORTE DE MATERIALES (3% DE MATERIALES) | 1d | 2022-08-24 | 2022-08-25 | 322 | 76d |  |
| 341 | 1.4.11 | **SISTEMA DE COMUNICACIONES** | 95d | 2022-08-02 | 2022-11-05 |  | 4d |  |
| 342 | 1.4.11.1 | **SISTEMA DE CABLEADO ESTRUCTURADO PARA DATA** | 95d | 2022-08-02 | 2022-11-05 |  | 4d |  |
| 343 | 1.4.11.1.1 | **CONDUCTOS PARA DATA** | 2d | 2022-08-02 | 2022-08-04 |  | 94d |  |
| 344 | 1.4.11.1.1.1 | TUBERIA PVC SAP 3" PARA RED DATA | 1d | 2022-08-02 | 2022-08-03 | 293 | 94d | 0d |
| 345 | 1.4.11.1.1.2 | TUBERIA PVC SAP 1" (25mm) PARA RED DATA | 1d | 2022-08-03 | 2022-08-04 | 344 | 94d | 0d |
| 346 | 1.4.11.1.2 | **MEDIOS DE TRANSMISION** | 3d | 2022-08-04 | 2022-08-07 |  | 94d |  |
| 347 | 1.4.11.1.2.1 | CABLE U/FTP CAT 6A, 23 AWG | 1d | 2022-08-04 | 2022-08-05 | 345 | 94d | 0d |
| 348 | 1.4.11.1.2.2 | CABLE DATA UTP CAT 6 | 1d | 2022-08-05 | 2022-08-06 | 347 | 94d | 0d |
| 349 | 1.4.11.1.2.3 | PATCH CORD CAT 6 DE 3m, 4PARES/24AWG | 1d | 2022-08-06 | 2022-08-07 | 348 | 94d |  |
| 350 | 1.4.11.1.3 | **EQUIPOS** | 6d | 2022-10-29 | 2022-11-04 |  | 2d |  |
| 351 | 1.4.11.1.3.1 | SUMINISTRO E INSTALACIÓN DE RACK DE 10RU ADOSADO DE 77X60X55cm | 1d | 2022-10-29 | 2022-10-30 | 202 | 2d | 0d |
| 352 | 1.4.11.1.3.2 | SUMINISTRO E INSTALACION DE RACK DE 4RU DE 24X50X38cm | 1d | 2022-10-30 | 2022-10-31 | 351 | 2d | 0d |
| 353 | 1.4.11.1.3.3 | SUMINISTRO E INSTALACION DE PATCH PANEL DE 48 PUERTOS (COMPLETO) | 1d | 2022-10-31 | 2022-11-01 | 352 | 2d | 0d |
| 354 | 1.4.11.1.3.4 | SUMINISTRO E INSTALACION DE SWICH DE 48 PUERTOS | 1d | 2022-11-01 | 2022-11-02 | 353 | 2d | 0d |
| 355 | 1.4.11.1.3.5 | SUMINISTRO E INSTALACION DE SERVIDOR HPE 16GB | 1d | 2022-11-02 | 2022-11-03 | 354 | 2d | 0d |
| 356 | 1.4.11.1.3.6 | SUMINISTRO E INSTALACION DE EQUIPO UPS 6 kVA | 1d | 2022-11-03 | 2022-11-04 | 355 | 2d | 0d |
| 357 | 1.4.11.1.4 | **ACCESORIOS DE CABLEADO ESTRUCUTURADO** | 2d | 2022-11-03 | 2022-11-05 |  | 2d |  |
| 358 | 1.4.11.1.4.1 | FACE PLATE 4 PUERTO | 1d | 2022-11-04 | 2022-11-05 | 356 | 4d |  |
| 359 | 1.4.11.1.4.2 | JACK CAT 6 | 1d | 2022-11-03 | 2022-11-04 | 356SS | 2d | 0d |
| 360 | 1.4.11.1.5 | **PRUEBAS DE COMUNICACIÓN** | 1d | 2022-11-04 | 2022-11-05 |  | 2d |  |
| 361 | 1.4.11.1.5.1 | PRUEBAS Y OPERACIONES DE LOS SISTEMAS DE COMUNICACIÓN | 1d | 2022-11-04 | 2022-11-05 | 359 | 2d | 0d |

| ID | WBS | Task | Duration | Start | Finish | Predecessors | Total slack |
| --- | --- | --- | --- | --- | --- | --- | --- |
| 362 | 1.4.12 | **CONEXION Y ADECUACION A RED DE ENERGIA EXISTENTE** | 2d | 2022-11-05 | 2022-11-07 |  | 2d |
| 363 | 1.4.12.1 | CONEXION Y ADECUACION A RED DE ENERGIA EXISTENTE (incluye todas las gestiones necesarias) | 2d | 2022-11-05 | 2022-11-07 | 361 | 2d |
